# Upgrade schedule from Jan 2010 (under review)

Schedule from MS Project XML, 2010-01-01 to 2023-07-07.

## Calendars

- Standard: Mon-Fri 08:00-12:00, 13:00-17:00; Sat-Sun off.

## Resources

| Resource |
| --- |
| C-Foudas |
| Greg-Iles |
| IC-NEW-ENG |
| LANL-TECH1 |
| RA1 |
| RAL-ENG1 |
| Stettler |
| design engineer |
| outside company |

## Schedule

| ID | WBS | Task | Type | Duration | Start | Predecessors | Total slack | Constraint | Work |
| --- | --- | --- | --- | --- | --- | --- | --- | --- | --- |
| 1 | 1 | **LHC plan (S Myers EPS 2011)** |  | 0d | 2010-07-01 |  | 0d | start no earlier than 2010-07-01 |  |
| 2 | 1.1 | 7 TeV operation |  | 642d | 2010-07-01 |  | 0d | must start on 2010-07-01 |  |
| 3 | 1.2 | LS1: Energy upgrade |  | 109w | 2012-12-17 | 2 | 0d |  |  |
| 4 | 1.3 | **prepare for parallel trigger** |  | 0d | 2013-01-01 | 3SS | 0d | start no earlier than 2013-01-01 |  |
| 5 | 1.3.1 | install & commission new trigger |  | 540d? | 2013-01-01 |  | 0d | start no earlier than 2013-01-01 | 4320h |
| 6 | 1.4 | 14 TeV operation to 10^34 |  | 152w | 2015-01-19 | 3 | 0d |  |  |
| 7 | 1.5 | LS2: Luminosity upgrade |  | 60w | 2017-12-18 | 6 | 0d |  |  |
| 8 | 1.6 | instal replacement pixel detector |  | 60w | 2017-12-18 | 7 | 0d |  |  |
| 9 | 1.7 | instal new trigger if not in LS1 |  | 60w | 2017-12-18 | 7 | 0d |  |  |
| 10 | 1.8 | possible Tracker FED modifications |  | 60w | 2017-12-18 | 7 | 0d |  |  |
| 11 | 1.9 | Beyond 10^34 operation |  | 145w | 2019-02-11 | 7 | 0d |  |  |
| 12 | 1.10 | High Lumi upgrade (duration not known) |  | 85w | 2021-11-22 | 11 | 0d |  |  |
| 13 | 2 | **CMS schedule - provisional!!** |  | 0d | 2010-01-01 |  | 0d |  |  |
| 14 | 2.1 | **Phase I Tracker (adapted from TP)** |  | 0d | 2011-07-01 |  | 0d |  |  |
| 15 | 2.1.1 | TDR (tbc) | milestone | 0h | 2012-04-01 |  | 0d | must start on 2012-04-01 |  |
| 16 | 2.1.2 | Development & construction |  | 71.8mo | 2011-07-01 |  | 0d | start no earlier than 2011-07-01 |  |
| 17 | 2.1.3 | System Integration |  | 240d | 2016-11-07 | 16FS-2mo | 0d |  |  |
| 18 | 2.1.4 | TIF long term test |  | 9mo | 2017-10-09 | 17 | 0d |  |  |
| 19 | 2.1.5 | Installation |  | 3mo | 2018-06-18 | 18, 7 | 0d | start no earlier than 2018-01-01 |  |
| 20 | 2.1.6 | Commissioning |  | 6mo | 2018-09-10 | 19 | 0d |  | 960h |
| 21 | 2.2 | **Phase I Trigger (adapted from TP)** |  | 0d | 2010-01-01 |  | 0d |  |  |
| 22 | 2.2.1 | Technology Demonstrator |  | 651d | 2010-01-01 |  | 0d | must finish on 2012-06-30 |  |
| 23 | 2.2.2 | TDR (tbc) | milestone | 0h | 2012-07-01 |  | 0d | start no earlier than 2012-07-01 |  |
| 24 | 2.2.3 | Prototype system for parallel operation |  | 33mo | 2012-07-02 |  | 0d | start no earlier than 2012-07-01 |  |
| 25 | 2.2.4 | Pre-production & test |  | 23mo | 2015-01-12 | 24 | 0d | start no earlier than 2012-08-01 |  |
| 26 | 2.2.5 | Construction and testing |  | 340d? | 2016-10-17 | 25 | 0d | start no earlier than 2016-10-01 | 2720h |
| 27 | 2.2.6 | Installation and test |  | 13mo | 2018-02-05 | 26 | 0d | start no earlier than 2018-01-01 |  |

| ID | WBS | Task | Type | Duration | Start | Predecessors | Total slack | Constraint | Work |
| --- | --- | --- | --- | --- | --- | --- | --- | --- | --- |
| 28 | 2.3 | **Phase I Trigger (for LS1)** |  | 0d | 2010-01-01 |  | 0d |  |  |
| 29 | 2.3.1 | Technology Demonstrator |  | 390d | 2010-01-01 |  | 0d | must finish on 2011-06-30 |  |
| 30 | 2.3.2 | Architecture decision | milestone | 0h | 2012-04-01 |  | 0d | start no earlier than 2012-04-01 |  |
| 31 | 2.3.3 | TDR | milestone | 0h | 2012-10-01 |  | 0d | start no earlier than 2012-10-01 |  |
| 32 | 2.3.4 | Maxi-T7 (TMT) development |  | 240d | 2011-10-03 |  | 0d | start no earlier than 2011-10-01 | 1920h |
| 33 | 2.3.5 | Mini-T7 + Alt-T7 (CT) development |  | 240d | 2011-10-03 |  | 0d | start no earlier than 2011-10-01 | 1920h |
| 34 | 2.3.6 | Infrastructure installation |  | 240d? | 2012-04-02 |  | 0d | start no earlier than 2012-04-01 | 1920h |
| 35 | 2.3.7 | Full system test |  | 240d | 2012-10-01 | 33, 32 | 0d | start no earlier than 2012-10-01 |  |
| 36 | 2.3.8 | Final Production |  | 240d | 2013-09-02 | 35 | 0d | start no earlier than 2012-08-01 |  |
| 37 | 2.3.9 | Installation and test |  | 6mo | 2014-08-04 | 36 | 0d | start no earlier than 2014-07-01 |  |
| 38 | 2.4 | **Phase II Tracker Upgrade** |  | 0d | 2011-04-19 |  | 0d | start no earlier than 2011-04-19 |  |
| 39 | 2.4.1 | Validation of final substrates design |  | 6mo | 2017-04-13 | 47SS+1mo, 43 | 0d | as late as possible | 8h |
| 40 | 2.4.2 | Study/design of trigger architecture |  | 624d | 2011-04-19 |  | 0d |  | 8h |
| 41 | 2.4.3 | Finalization of detector layout |  | 6mo | 2014-07-10 | 40 | 0d | as late as possible | 8h |
| 42 | 2.4.4 | Final system test |  | 6mo | 2017-09-28 | 39, 45, 47 | 0d | as late as possible | 8h |
| 43 | 2.4.5 | Final substrates design/preproduction |  | 288d | 2016-02-08 | 51 | 0d | as late as possible | 8h |
| 44 | 2.4.6 | Final design module mechanics |  | 9mo | 2016-02-18 | 51, 76, 75 | 0d | as late as possible | 8h |
| 45 | 2.4.7 | Procurement of final frames prototypes |  | 240d | 2016-10-27 | 44 | 0d | as late as possible | 8h |
| 46 | 2.4.8 | Final ASICs design/preproduction |  | 360d | 2015-10-29 | 51 | 0d | as late as possible | 8h |
| 47 | 2.4.9 | Validation of final ASICs |  | 6mo | 2017-03-16 | 46, 43 | 0d | as late as possible | 8h |
| 48 | 2.4.10 | Substrates prototype testing |  | 6mo | 2014-11-27 | 53, 74SS+1mo | 0d | as late as possible | 8h |
| 49 | 2.4.11 | Financial planning, costbook |  | 360d | 2014-12-25 | 41 | 0d |  | 8h |
| 50 | 2.4.12 | Commercial actions (ASICs etc.) |  | 480d | 2016-05-12 | 51, 49 | 0d |  | 8h |
| 51 | 2.4.13 | Prototype system test |  | 6mo | 2015-05-14 | 74, 75SS+3mo, 76SS+3mo, 48 | 0d | as late as possible | 8h |
| 52 | 2.4.14 | Substrates prototype design |  | 240d | 2013-01-24 | 67, 72SS, 69 | 0d | as late as possible | 8h |
| 53 | 2.4.15 | Substrates prototypes fabrication |  | 240d | 2013-12-26 | 52 | 0d | as late as possible | 8h |

| ID | WBS | Task | Type | Duration | Start | Predecessors | Total slack | Constraint | Work |
| --- | --- | --- | --- | --- | --- | --- | --- | --- | --- |
| 54 | 2.4.16 | **Modules construction** |  | 0d | 2018-03-15 | 42, 50 | 0d |  |  |
| 55 | 2.4.16.1 | Procurement of hybrids |  | 360d | 2018-06-07 | 39 | 0d | as late as possible | 8h |
| 56 | 2.4.16.2 | Procurement of module mechanics |  | 360d | 2018-06-07 |  | 0d | as late as possible | 8h |
| 57 | 2.4.16.3 | Procurement of optical links |  | 240d | 2018-06-07 |  | 0d | as late as possible | 8h |
| 58 | 2.4.16.4 | Procurement of sensors |  | 288d | 2018-03-15 |  | 0d | as late as possible | 8h |
| 59 | 2.4.16.5 | Modules assembly |  | 480d | 2018-08-30 | 56SS+3mo, 55SS+3mo, 58SS+6mo, 57SS+3mo | 0d | finish no later than 2020-07-01 | 8h |
| 60 | 2.4.17 | Design of back-end systems |  | 720d | 2016-05-23 | 41 | 0d | as late as possible | 8h |
| 61 | 2.4.18 | Production of back-end systems |  | 960d | 2019-02-25 | 60 | 0d | as late as possible | 8h |
| 62 | 2.4.19 | **Mechanical structures** |  | 0d | 2015-09-14 | 41 | 0d |  |  |
| 63 | 2.4.19.1 | Procurement of mechanical structures |  | 360d | 2019-05-20 | 66 | 0d | as late as possible | 8h |
| 64 | 2.4.19.2 | Mech. struct. design |  | 480d | 2015-09-14 |  | 0d | as late as possible | 8h |
| 65 | 2.4.19.3 | Mech. struct. proto construction |  | 240d | 2017-07-17 | 64 | 0d | as late as possible | 8h |
| 66 | 2.4.19.4 | Mech. struct. proto validation |  | 240d | 2018-06-18 | 65 | 0d | as late as possible | 8h |
| 67 | 2.4.20 | Study of substrate technologies |  | 336d | 2011-04-19 |  | 0d |  | 8h |
| 68 | 2.4.21 | Options for opto packaging |  | 336d | 2011-04-19 | 70FF | 0d |  | 8h |
| 69 | 2.4.22 | Design of electronics system |  | 336d | 2011-04-19 | 70FF | 0d |  | 8h |
| 70 | 2.4.23 | Materials and technologies for module mechanics |  | 336d | 2011-04-19 | 67FF | 0d |  | 8h |
| 71 | 2.4.24 | Design of module mechanics |  | 240d | 2013-04-18 | 72SS, 70 | 0d | as late as possible |  |
| 72 | 2.4.25 | ASICs prototypes design |  | 240d | 2012-12-27 | 69, 68 | 0d | as late as possible | 8h |
| 73 | 2.4.26 | Fabrication of frames prototypes |  | 240d | 2014-03-20 | 71 | 0d | as late as possible | 8h |
| 74 | 2.4.27 | ASICs prototypes testing |  | 6mo | 2014-10-30 | 77 | 0d | as late as possible | 8h |
| 75 | 2.4.28 | Module design thermal validation |  | 240d | 2015-02-19 | 73 | 0d | as late as possible | 8h |
| 76 | 2.4.29 | Module design mechanical validation |  | 9mo | 2015-02-19 | 73 | 0d | as late as possible | 8h |
| 77 | 2.4.30 | ASICs prototypes fabrication |  | 240d | 2013-11-28 | 72 | 0d | as late as possible | 8h |
| 78 | 2.4.31 | Procurement of services |  | 9mo | 2020-04-20 |  | 0d | as late as possible | 8h |
| 79 | 2.4.32 | Tracker commissioning |  | 9mo | 2022-10-31 | 61, 82FS+6mo | 0d | as late as possible |  |
| 80 | 2.4.33 | Subdetectors integration |  | 240d | 2020-12-28 | 59FF+3mo, 78, 62FS+3mo | 0d | as late as possible |  |
| 81 | 2.4.34 | Tracker delivered to P5 | milestone | 0h | 2023-07-07 | 79 | 0d | start no earlier than 2021-12-21 |  |
| 82 | 2.4.35 | Tracker integration |  | 6mo | 2021-11-29 | 80 | 0d | as late as possible | 8h |

| ID | WBS | Task | Type | Duration | Start | Predecessors | Total slack | Constraint | Work |
| --- | --- | --- | --- | --- | --- | --- | --- | --- | --- |
| 83 | 3 | **UK R&D** |  | 0d | 2010-01-01 |  | 0d |  |  |
| 84 | 3.1 | **WP1** |  | 0d | 2010-07-30 |  | 0d |  |  |
| 85 | 3.1.1 | Documented requirements M1.1.1 | milestone | 0h | 2010-10-30 |  | 0d | must start on 2010-10-30 |  |
| 86 | 3.1.2 | **Detector simulations** |  | 0d | 2010-07-30 |  | 0d |  |  |
| 87 | 3.1.2.1 | Benchmark channels chosen M1.1.2 | milestone | 0h | 2011-01-28 |  | 0d | start no earlier than 2011-01-28 |  |
| 88 | 3.1.2.2 | Simulation code for Phase I tracker M1.2.3 | milestone | 0h | 2010-07-30 |  | 0d | start no earlier than 2010-07-30 |  |
| 89 | 3.1.2.3 | Results for TP |  | 12mo | 2010-07-30 | 88 | 0d |  |  |
| 90 | 3.1.2.4 | Release baseline sim/recon code M1.3.7 | milestone | 0h | 2011-12-16 |  | 0d | start no earlier than 2011-12-16 |  |
| 91 | 3.1.2.5 | Simulation of upgrade tracker M1.3.10 | milestone | 0h | 2012-07-01 |  | 0d | start no earlier than 2012-07-01 |  |
| 92 | 3.1.3 | **Trigger online software & firmware** |  | 0d | 2010-12-16 |  | 0d |  |  |
| 93 | 3.1.3.1 | Trigger emulation package M1.2.2 | milestone | 0h | 2010-12-16 |  | 0d | start no earlier than 2010-12-16 |  |
| 94 | 3.1.3.2 | Trigger software development |  | 6mo | 2010-12-16 | 93 | 0d |  |  |
| 95 | 3.1.3.3 | Trigger platform tests |  | 6mo | 2011-06-02 | 94 | 0d |  |  |
| 96 | 3.1.3.4 | Release core online FW/SW system M1.3.6 | milestone | 0h | 2011-10-31 |  | 0d | start no earlier than 2011-10-31 |  |
| 97 | 3.1.3.5 | Simulation of new L1 CAL algo M1.3.8 | milestone | 0h | 2012-04-01 |  | 0d | start no earlier than 2012-04-01 |  |
| 98 | 3.1.3.6 | V2 core online FW/SW M1.3.9 | milestone | 0h | 2012-07-01 |  | 0d | start no earlier than 2012-07-01 |  |
| 99 | 3.2 | **WP2** |  | 0d | 2010-01-01 |  | 0d |  |  |
| 100 | 3.2.1 | **FE chip prototype** |  | 0d | 2010-07-05 |  | 0d |  |  |
| 101 | 3.2.1.1 | CBC submission M2.2.2 | milestone | 0h | 2010-07-05 |  | 0d | must start on 2010-07-05 |  |
| 102 | 3.2.1.2 | Review of options for next CBC M2.2.5 | milestone | 0h | 2011-10-01 |  | 0d | start no earlier than 2011-10-01 |  |
| 103 | 3.2.1.3 | CBC test beam studies |  | 1mo | 2011-08-22 |  | 0d | start no earlier than 2011-08-22 |  |
| 104 | 3.2.1.4 | CBC results presented M2.3.3 | milestone | 0h | 2011-09-28 |  | 0d | must start on 2011-09-28 |  |
| 105 | 3.2.1.5 | CBC v2 submission M2.3.4 | milestone | 0h | 2012-03-01 |  | 0d | must start on 2012-03-01 |  |
| 106 | 3.2.1.6 | CBC-2 BB module development |  | 240d? | 2011-10-03 |  | 0d | start no earlier than 2011-10-01 | 1920h |
| 107 | 3.2.1.7 | CBC radiation tests |  | 6mo? | 2012-07-02 |  | 0d | start no earlier than 2012-07-01 | 960h |
| 108 | 3.2.1.8 | CBC-2 results M2.4.1 | milestone | 0h | 2012-09-28 |  | 0d | must start on 2012-09-28 |  |

| ID | WBS | Task | Type | Duration | Start | Predecessors | Total slack | Constraint | Work |
| --- | --- | --- | --- | --- | --- | --- | --- | --- | --- |
| 109 | 3.2.2 | **FED development** |  | 0d | 2011-12-30 |  | 0d |  |  |
| 110 | 3.2.2.1 | FPGA designs for miniT M2.3.8 | milestone | 0h | 2011-12-30 |  | 0d | start no earlier than 2011-12-30 |  |
| 111 | 3.2.2.2 | System test with single link M2.3.6 | milestone | 0h | 2012-12-30 |  | 0d | start no earlier than 2012-12-30 |  |
| 112 | 3.2.3 | **module and system tests** |  | 0d | 2010-01-01 |  | 0d |  |  |
| 113 | 3.2.3.1 | powering studies (now CERN) |  | 480d | 2010-01-01 |  | 0d | start no earlier than 2008-03-31 |  |
| 114 | 3.2.3.2 | module and system tests |  | 6mo | 2012-10-01 |  | 0d | start no earlier than 2012-10-01 |  |
| 115 | 3.3 | **WP3** |  | 0d | 2010-01-01 |  | 0d |  |  |
| 116 | 3.3.1 | **Processing cards** |  | 0d | 2010-01-01 |  | 0d |  |  |
| 117 | 3.3.1.1 | Design Main Processing Card M3.1.1 | milestone | 0h | 2010-01-01 |  | 0d | must start on 2010-01-01 |  |
| 118 | 3.3.1.2 | MPC Fimware & software development |  | 42mo | 2010-01-01 |  | 0d |  |  |
| 119 | 3.3.1.3 | Working prototype M3.2.1 | milestone | 0h | 2010-10-29 |  | 0d | start no earlier than 2010-10-29 |  |
| 120 | 3.3.1.4 | First µTCA demonstrator M3.2.2 | milestone | 0h | 2011-06-30 |  | 0d | start no earlier than 2011-06-30 |  |
| 121 | 3.3.1.5 | Final trigger card tested M3.3.7 | milestone | 0h | 2012-06-29 |  | 0d | start no earlier than 2012-06-29 |  |
| 122 | 3.3.1.6 | System development |  | 10mo | 2012-06-29 | 121 | 0d |  |  |
| 123 | 3.3.2 | **Firmware Algorithm Development (see also WP1)** |  | 0d | 2011-03-30 |  | 0d |  |  |
| 124 | 3.3.2.1 | Core firmware infrastructure M3.3.4 | milestone | 0h | 2011-04-01 |  | 0d | start no earlier than 2011-04-01 |  |
| 125 | 3.3.2.2 | Client side software | milestone | 0h | 2011-04-01 |  | 0d | start no earlier than 2011-04-01 |  |
| 126 | 3.3.2.3 | e/tau core firmware M3.3.3 | milestone | 0h | 2011-03-30 |  | 0d | must start on 2011-03-30 |  |
| 127 | 3.3.2.4 | Results from algorithm simulations M3.2.3 | milestone | 0h | 2011-06-30 |  | 0d | start no earlier than 2011-06-30 |  |
| 128 | 3.3.2.5 | Algorithm performance studies M3.3.1 | milestone | 0h | 2012-04-01 |  | 0d | start no earlier than 2012-04-01 |  |
| 129 | 3.3.2.6 | Algorithm performance studies... |  | 240d? | 2012-04-02 | 128 | 0d |  | 1920h |
| 130 | 3.3.2.7 | jet core firmware M3.3.3 | milestone | 0h | 2012-06-30 |  | 0d | must start on 2012-06-30 |  |
| 131 | 3.3.2.8 | System design M3.3.6 | milestone | 0h | 2011-08-31 |  | 0d | start no earlier than 2011-08-31 |  |
| 132 | 3.4 | **Phase I planning** |  | 0d | 2010-07-01 |  | 0d |  |  |
| 133 | 3.4.1 | Evaluation of pixel module development |  | 10mo | 2010-07-01 |  | 0d | start no earlier than 2010-07-01 |  |
| 134 | 3.4.2 | Evaluation of pixel DAQ contribution |  | 10mo | 2011-01-03 |  | 0d | start no earlier than 2011-01-01 |  |
| 135 | 3.4.3 | Trigger architecture decision | milestone | 0h | 2012-04-01 | 30SS | 0d |  |  |
| 136 | 3.4.4 | Tracker DAQ upgrade definition | milestone | 0h | 2012-01-01 | 134 | 0d | start no earlier than 2012-01-01 |  |
| 137 | 3.4.5 | Decisions on contributions to Phase I |  | 6mo | 2011-10-17 | 136SF, 135FF | 0d | start no earlier than 2011-10-01 |  |
| 138 | 3.4.6 | Proposal preparation & approval |  | 240d | 2012-04-02 | 137 | 0d |  |  |
